# ESMCP Imp Plan v1

Schedule from MS Project, 2015-08-31 to 2020-09-21.
KBR

## Calendars

- Standard: Mon-Fri 08:00-12:00, 13:00-17:00; Sat-Sun off.

## Schedule

| ID | WBS | Task | Type | Duration | Start | Finish | Predecessors | Total slack | Free slack |
| --- | --- | --- | --- | --- | --- | --- | --- | --- | --- |
| 1 | 1 | Effective Date | milestone, manual | 0d | 2015-09-01 | 2015-09-01 |  |  |  |
| 3 | 2 | **Mobilisation** |  | 459d | 2015-08-31 | 2017-06-01 |  | 669d |  |
| 4 | 2.1 | Detailed Implementation Plan Delivered and Approved |  | 25d | 2015-09-08 | 2015-10-12 | 15FF | 1290d |  |
| 5 | 2.2 | Documentary Deliverables Schedule delivered and approved |  | 25d | 2015-09-08 | 2015-10-12 | 15FF | 1290d |  |
| 6 | 2.3 | Security Management Policy delivered and approved |  | 25d | 2015-09-08 | 2015-10-12 | 15FF | 1290d |  |
| 7 | 2.4 | Security Management Plan delivered and approved |  | 18d | 2015-09-17 | 2015-10-12 | 15FF | 1290d |  |
| 8 | 2.5 | Security Test Results Template delivered and approved |  | 5d | 2015-10-06 | 2015-10-12 | 15FF | 1290d |  |
| 9 | 2.6 | Risk Management Plan delivered and approved |  | 25d | 2015-09-08 | 2015-10-12 | 15FF | 1290d |  |
| 10 | 2.7 | ESN Co-ordination Office Implementation and Management Plan delivered and approved |  | 25d | 2015-09-08 | 2015-10-12 | 15FF | 1290d |  |
| 11 | 2.8 | ESN Supplier Implementation Progress Report Template delivered and approved |  | 24d | 2015-09-09 | 2015-10-12 | 15FF | 1290d |  |
| 12 | 2.9 | Supplier Assurance Strategy delivered and approved |  | 25d | 2015-09-08 | 2015-10-12 | 15FF | 1290d |  |
| 13 | 2.10 | Programme Execution Plan delivered and approved |  | 25d | 2015-09-08 | 2015-10-12 | 15FF | 1290d |  |
| 14 | 2.11 | Template invoice delivered and approved |  | 18d | 2015-09-17 | 2015-10-12 | 15FF | 1290d |  |
| 15 | 2.12 | L1.01.5 Initial Mobilisation | milestone | 0d | 2015-10-12 | 2015-10-12 | 1FF+30d | 1290d | 0d |
| 16 | 2.13 | Integrated ESN Implementation Plan delivered and approved |  | 71d | 2015-08-31 | 2015-12-07 | 17FF | 1250d |  |
| 17 | 2.14 | L1.03 - Integrated Implementation Plan | milestone | 0d | 2015-12-01 | 2015-12-01 | 1FF+66d | 1254d | 4d |
| 18 | 2.15 | ESN Co-ordination Office available for occupation delivered and approved |  | 45d | 2015-12-01 | 2016-02-01 | 20FF | 1210d |  |
| 19 | 2.16 | Draft Exit Plan delivered and approved |  | 30d | 2015-12-22 | 2016-02-01 | 20FF | 1210d |  |
| 20 | 2.17 | L1.06 - Design Baselined | milestone | 0d | 2016-02-01 | 2016-02-01 | 1FF+110d | 1210d | 0d |
| 21 | 2.18 | Reference vehicle designs delivered and approved |  | 78d | 2016-01-14 | 2016-05-02 | 22FF | 1145d |  |
| 22 | 2.19 | L1.12a - Reference Vehicle Designs | milestone | 0d | 2016-05-02 | 2016-05-02 | 1FF+175d | 1145d | 0d |
| 23 | 2.20 | System Test Assurance Plan delivered and approved |  | 40d | 2016-05-09 | 2016-07-01 | 33FF | 1101d |  |
| 24 | 2.21 | US Supplier, MS Supplier and ES Supplier System Test Readiness Reviews assured |  | 33d | 2016-05-18 | 2016-07-01 | 33FF | 1101d |  |
| 25 | 2.22 | System Test Assurance report delivered and approved |  | 25d | 2016-05-30 | 2016-07-01 | 33FF | 1101d |  |
| 26 | 2.23 | US Supplier, MS Supplier and ES Supplier System Test Completion Reviews assured |  | 33d | 2016-05-18 | 2016-07-01 | 33FF | 1101d |  |
| 27 | 2.24 | ESN Training Needs Analysis and Training Strategy delivered and approved |  | 53d | 2016-04-20 | 2016-07-01 | 33FF | 1101d |  |
| 28 | 2.25 | Reference Training Materials delivered and approved |  | 68d | 2016-03-30 | 2016-07-01 | 33FF | 1101d |  |
| 29 | 2.26 | Reference Business Readiness Assessments delivered and approved |  | 39d | 2016-05-10 | 2016-07-01 | 33FF | 1101d |  |
| 30 | 2.27 | Reference Technical Readiness Assessments delivered and approved |  | 40d | 2016-05-09 | 2016-07-01 | 33FF | 1101d |  |
| 31 | 2.28 | National Transition Plan delivered and approved |  | 112d | 2016-01-28 | 2016-07-01 | 33FF | 1101d |  |
| 32 | 2.29 | Personnel Security Risk Assessment complete |  | 84d | 2016-03-08 | 2016-07-01 | 33FF | 1101d |  |
| 33 | 2.30 | L1.12 - System Test Complete | milestone | 0d | 2016-07-01 | 2016-07-01 | 1FF+219d | 1101d | 0d |
| 34 | 2.31 | Integration Test Assurance Plan delivered and approved |  | 35d | 2016-11-15 | 2017-01-02 | 43FF | 970d |  |
| 35 | 2.32 | US Supplier, MS Supplier and ES Supplier Integration Test Readiness Reviews assured |  | 35d | 2016-11-15 | 2017-01-02 | 43FF | 970d |  |
| 36 | 2.33 | Integration Testing Assurance Report Delivered and Approved |  | 35d | 2016-11-15 | 2017-01-02 | 43FF | 970d |  |
| 37 | 2.34 | US Supplier, MS Supplier and ES Supplier Integration Test Completion Reviews assured |  | 11d | 2016-12-19 | 2017-01-02 | 43FF | 970d |  |
| 38 | 2.35 | Performance Test Assurance Plan delivered and approved |  | 35d | 2016-11-15 | 2017-01-02 | 43FF | 970d |  |
| 39 | 2.36 | US Supplier, MS Supplier and ES Supplier Performance Test Readiness Reviews assured |  | 34d | 2016-11-16 | 2017-01-02 | 43FF | 970d |  |
| 40 | 2.37 | Performance Testing Assurance Report delivered and approved |  | 35d | 2016-11-15 | 2017-01-02 | 43FF | 970d |  |
| 41 | 2.38 | US Supplier, MS Supplier and ES Supplier Performance Test Completion Reviews assured |  | 12d | 2016-12-16 | 2017-01-02 | 43FF | 970d |  |
| 42 | 2.39 | Pilot Test Plans for nominated Transition Group delivered and approved |  | 27d | 2016-11-25 | 2017-01-02 | 43FF | 970d |  |
| 43 | 2.40 | L1.16 - Integration and Performance Testing Complete | milestone | 0d | 2017-01-02 | 2017-01-02 | 1FF+350d | 970d | 0d |
| 44 | 2.41 | User Acceptance Test Plan delivered and approved |  | 35d | 2017-02-14 | 2017-04-03 | 52FF | 905d |  |
| 45 | 2.42 | US Supplier, MS Supplier and ES Supplier User Acceptance Test Readiness Reviews assured |  | 11d | 2017-03-20 | 2017-04-03 | 52FF | 905d |  |
| 46 | 2.43 | User Acceptance Test Report Delivered and Approved |  | 27d | 2017-02-24 | 2017-04-03 | 52FF | 905d |  |
| 47 | 2.44 | US Supplier, MS Supplier and ES Supplier User Acceptance Test Completion Reviews assured |  | 10d | 2017-03-21 | 2017-04-03 | 52FF | 905d |  |
| 48 | 2.45 | Operational Acceptance Test Assurance Plan delivered and approved |  | 35d | 2017-02-14 | 2017-04-03 | 52FF | 905d |  |
| 49 | 2.46 | US Supplier, MS Supplier and ES Supplier Operational Acceptance Test Readiness Reviews assured |  | 11d | 2017-03-20 | 2017-04-03 | 52FF | 905d |  |
| 50 | 2.47 | Operational Acceptance Testing Assurance Report Delivered and Approved |  | 11d | 2017-03-20 | 2017-04-03 | 52FF | 905d |  |
| 51 | 2.48 | US Supplier, MS Supplier and ES Supplier Operational Acceptance Test Completion Reviews assured |  | 5d | 2017-03-28 | 2017-04-03 | 52FF | 905d |  |
| 52 | 2.49 | L1.19 - User Acceptance and Operational Acceptance Testing Complete | milestone | 0d | 2017-04-03 | 2017-04-03 | 1FF+415d | 905d | 0d |
| 53 | 2.50 | Assurance of service support, management processes and resources are in place |  | 34d | 2017-04-17 | 2017-06-01 | 62FF | 862d |  |
| 54 | 2.51 | User Organisation Service Acceptance Testing Test Plan Assured |  | 30d | 2017-04-21 | 2017-06-01 | 62FF | 862d |  |
| 55 | 2.52 | Service Acceptance Test reports delivered and approved |  | 20d | 2017-05-05 | 2017-06-01 | 62FF | 862d |  |
| 56 | 2.53 | Service Acceptance Testing completion review successfully completed |  | 10d | 2017-05-19 | 2017-06-01 | 62FF | 862d |  |
| 57 | 2.54 | Pilot Test Readiness Review Successfully Completed for nominated Transition Group |  | 40d | 2017-04-07 | 2017-06-01 | 62FF | 862d |  |
| 58 | 2.55 | Pilot Test Report delivered and approved for nominated Transition Group |  | 5d | 2017-05-26 | 2017-06-01 | 62FF | 862d |  |
| 59 | 2.56 | Pilot Test completion review successfully completed for nominated Transition Group |  | 60d | 2017-03-10 | 2017-06-01 | 62FF | 862d |  |
| 60 | 2.57 | Business Continuity Management System in place |  | 72d | 2017-02-22 | 2017-06-01 | 62FF | 862d |  |
| 61 | 2.58 | ISO 27001 Certified Information Security Management System |  | 72d | 2017-02-22 | 2017-06-01 | 62FF | 862d |  |
| 62 | 2.59 | L1.21 - Mobilisation Complete | milestone | 0d | 2017-06-01 | 2017-06-01 | 1FF+458d | 210d | 0d |

| ID | WBS | Task | Type | Duration | Start | Finish | Predecessors | Total slack | Free slack |
| --- | --- | --- | --- | --- | --- | --- | --- | --- | --- |
| 63 | 3 | **Transition** |  | 969d | 2017-01-04 | 2020-09-21 |  | 0d |  |
| 64 | 3.1 | **North West** |  | 368d | 2017-01-04 | 2018-06-01 |  | 601d |  |
| 65 | 3.1.1 | Group Transition Plan delivered and approved |  | 40d | 2017-01-04 | 2017-03-01 | 66FF | 929d |  |
| 66 | 3.1.2 | L1.20 - NW Transition Plan | milestone | 0d | 2017-03-01 | 2017-03-01 | 62FS-67d | 929d | 0d |
| 67 | 3.1.3 | Group Transition Commencement Criteria met |  | 97d | 2017-01-18 | 2017-06-01 | 68FF | 862d |  |
| 68 | 3.1.4 | L1.24 - NW Transition commencement | milestone | 0d | 2017-06-01 | 2017-06-01 | 62FF | 862d | 0d |
| 69 | 3.1.5 | Group Transition Completion Report delivered and approved |  | 30d | 2018-04-23 | 2018-06-01 | 70FF | 601d |  |
| 70 | 3.1.6 | L1.36 - NW Transition complete | milestone | 0d | 2018-06-01 | 2018-06-01 | 62FF+261d | 601d | 0d |
| 71 | 3.2 | **National** |  | 387d | 2017-03-10 | 2018-09-03 |  | 535d |  |
| 72 | 3.2.1 | Group Transition Plan delivered and approved |  | 60d | 2017-03-10 | 2017-06-01 | 73FF | 862d |  |
| 73 | 3.2.2 | L1.17.1 - National Group Transition Plan | milestone | 0d | 2017-06-01 | 2017-06-01 | 62FF | 862d | 0d |
| 74 | 3.2.3 | Group Transition Commencement Criteria met |  | 112d | 2017-03-30 | 2017-09-01 | 75FF | 796d |  |
| 75 | 3.2.4 | L1.21.2 - National Group Transition commencement | milestone | 0d | 2017-09-01 | 2017-09-01 | 62FF+66d | 796d | 0d |
| 76 | 3.2.5 | Group Transition Completion Report delivered and approved |  | 30d | 2018-07-24 | 2018-09-03 | 77FF | 535d |  |
| 77 | 3.2.6 | L1.33.1 - National Group Transition complete | milestone | 0d | 2018-09-03 | 2018-09-03 | 62FF+327d | 535d | 0d |
| 78 | 3.3 | **East Midlands** |  | 367d | 2017-04-07 | 2018-09-03 |  | 535d |  |
| 79 | 3.3.1 | Group Transition Plan delivered and approved |  | 40d | 2017-04-07 | 2017-06-01 | 80FF | 862d |  |
| 80 | 3.3.2 | L1.17 - East Mids Transition Plan | milestone | 0d | 2017-06-01 | 2017-06-01 | 62FF | 862d | 0d |
| 81 | 3.3.3 | Group Transition Commencement Criteria met |  | 69d | 2017-05-30 | 2017-09-01 | 82FF | 796d |  |
| 82 | 3.3.4 | L1.21.1 - East Mids Transition commencement | milestone | 0d | 2017-09-01 | 2017-09-01 | 62FF+66d | 796d | 0d |
| 83 | 3.3.5 | Group Transition Completion Report delivered and approved |  | 30d | 2018-07-24 | 2018-09-03 | 84FF | 535d |  |
| 84 | 3.3.6 | L1.33 - East Mids Transition complete | milestone | 0d | 2018-09-03 | 2018-09-03 | 62FF+327d | 535d | 0d |
| 85 | 3.4 | **London** |  | 461d | 2017-03-28 | 2019-01-01 |  | 449d |  |
| 86 | 3.4.1 | Group Transition Plan delivered and approved |  | 40d | 2017-04-07 | 2017-06-01 | 87FF | 862d |  |
| 87 | 3.4.2 | L1.35.1 - London Transition Plan | milestone | 0d | 2017-06-01 | 2017-06-01 | 62FF | 862d | 0d |
| 88 | 3.4.3 | Group Transition Commencement Criteria met |  | 114d | 2017-03-28 | 2017-09-01 | 89FF | 796d |  |
| 89 | 3.4.4 | L1.39 - London Transition commencement | milestone | 0d | 2017-09-01 | 2017-09-01 | 62FF+66d | 796d | 0d |
| 90 | 3.4.5 | Group Transition Completion Report delivered and approved |  | 30d | 2018-11-21 | 2019-01-01 | 92FF | 449d |  |
| 91 | 3.4.6 | No outstanding rectification issues |  | 30d | 2018-11-21 | 2019-01-01 | 92FF | 449d |  |
| 92 | 3.4.7 | L1.55.1 - London Transition complete | milestone | 0d | 2019-01-01 | 2019-01-01 | 62FF+413d | 449d | 0d |

| ID | WBS | Task | Type | Duration | Start | Finish | Predecessors | Total slack | Free slack |
| --- | --- | --- | --- | --- | --- | --- | --- | --- | --- |
| 93 | 3.5 | **South Central** |  | 365d | 2017-05-09 | 2018-10-01 |  | 515d |  |
| 94 | 3.5.1 | Group Transition Plan delivered and approved |  | 40d | 2017-05-09 | 2017-07-03 | 95FF | 840d |  |
| 95 | 3.5.2 | L1.48 - SC Transition Plan | milestone | 0d | 2017-07-03 | 2017-07-03 | 62FF+22d | 840d | 0d |
| 96 | 3.5.3 | Group Transition Commencement Criteria met |  | 91d | 2017-05-29 | 2017-10-02 | 97FF | 775d |  |
| 97 | 3.5.4 | L1.52 - SC Transition commencement | milestone | 0d | 2017-10-02 | 2017-10-02 | 62FF+87d | 775d | 0d |
| 98 | 3.5.5 | Group Transition Completion Report delivered and approved |  | 30d | 2018-08-21 | 2018-10-01 | 99FF | 515d |  |
| 99 | 3.5.6 | L1.64 - SC Transition complete | milestone | 0d | 2018-10-01 | 2018-10-01 | 62FF+347d | 515d | 0d |
| 100 | 3.6 | **North East** |  | 365d | 2017-05-09 | 2018-10-01 |  | 515d |  |
| 101 | 3.6.1 | Group Transition Plan delivered and approved |  | 40d | 2017-05-09 | 2017-07-03 | 102FF | 840d |  |
| 102 | 3.6.2 | L1.27 - NE Transition Plan | milestone | 0d | 2017-07-03 | 2017-07-03 | 62FS+22d | 840d | 0d |
| 103 | 3.6.3 | Group Transition Commencement Criteria met |  | 91d | 2017-05-29 | 2017-10-02 | 104FF | 775d |  |
| 104 | 3.6.4 | L1.31 - NE Transition commencement | milestone | 0d | 2017-10-02 | 2017-10-02 | 62FF+87d | 775d | 0d |
| 105 | 3.6.5 | Group Transition Completion Report delivered and approved |  | 30d | 2018-08-21 | 2018-10-01 | 106FF | 515d |  |
| 106 | 3.6.6 | L1.43 - NE Transition complete | milestone | 0d | 2018-10-01 | 2018-10-01 | 62FF+347d | 515d | 0d |
| 107 | 3.7 | **East** |  | 367d | 2017-06-07 | 2018-11-01 |  | 492d |  |
| 108 | 3.7.1 | Group Transition Plan delivered and approved |  | 40d | 2017-06-07 | 2017-08-01 | 109FF | 819d |  |
| 109 | 3.7.2 | L1.24.1 - East Transition Plan | milestone | 0d | 2017-08-01 | 2017-08-01 | 62FS+43d | 819d | 0d |
| 110 | 3.7.3 | Group Transition Commencement Criteria met |  | 91d | 2017-06-28 | 2017-11-01 | 111FF | 753d |  |
| 111 | 3.7.4 | L1.28 - East Transition commencement | milestone | 0d | 2017-11-01 | 2017-11-01 | 62FF+109d | 753d | 0d |
| 112 | 3.7.5 | Group Transition Completion Report delivered and approved |  | 30d | 2018-09-21 | 2018-11-01 | 113FF | 492d |  |
| 113 | 3.7.6 | L1.40 - East Transition complete | milestone | 0d | 2018-11-01 | 2018-11-01 | 62FF+370d | 492d | 0d |
| 114 | 3.8 | **Yorkshire** |  | 366d | 2017-08-08 | 2019-01-01 |  | 449d |  |
| 115 | 3.8.1 | Group Transition Plan delivered and approved |  | 40d | 2017-08-08 | 2017-10-02 | 116FF | 775d |  |
| 116 | 3.8.2 | L1.25 - Yorkshire Transition Plan | milestone | 0d | 2017-10-02 | 2017-10-02 | 62FF+87d | 775d | 0d |
| 117 | 3.8.3 | Group Transition Commencement Criteria met |  | 92d | 2017-08-25 | 2018-01-01 | 118FF | 710d |  |
| 118 | 3.8.4 | L1.34 - Yorkshire Transition commencement | milestone | 0d | 2018-01-01 | 2018-01-01 | 62FF+152d | 710d | 0d |
| 119 | 3.8.5 | Group Transition Completion Report delivered and approved |  | 30d | 2018-11-21 | 2019-01-01 | 120FF | 449d |  |
| 120 | 3.8.6 | L1.56 - Yorkshire Transition complete | milestone | 0d | 2019-01-01 | 2019-01-01 | 62FF+413d | 449d | 0d |

| ID | WBS | Task | Type | Duration | Start | Finish | Predecessors | Total slack | Free slack |
| --- | --- | --- | --- | --- | --- | --- | --- | --- | --- |
| 121 | 3.9 | **West Midlands** |  | 367d | 2017-09-07 | 2019-02-01 |  | 426d |  |
| 122 | 3.9.1 | Group Transition Plan delivered and approved |  | 40d | 2017-09-07 | 2017-11-01 | 123FF | 753d |  |
| 123 | 3.9.2 | L1.31.1 - West Mids Transition Plan | milestone | 0d | 2017-11-01 | 2017-11-01 | 62FF+109d | 753d | 0d |
| 124 | 3.9.3 | Group Transition Commencement Criteria met |  | 98d | 2017-09-19 | 2018-02-01 | 125FF | 687d |  |
| 125 | 3.9.4 | L1.35 - West Mids Transition commencement | milestone | 0d | 2018-02-01 | 2018-02-01 | 62FF+175d | 687d | 0d |
| 126 | 3.9.5 | Group Transition Completion Report delivered and approved |  | 30d | 2018-12-24 | 2019-02-01 | 127FF | 426d |  |
| 127 | 3.9.6 | L1.47 - West Mids Transition complete | milestone | 0d | 2019-02-01 | 2019-02-01 | 62FF+436d | 426d | 0d |
| 128 | 3.10 | **South East** |  | 410d | 2018-01-05 | 2019-08-01 |  | 297d |  |
| 129 | 3.10.1 | Group Transition Plan delivered and approved |  | 40d | 2018-01-05 | 2018-03-01 | 130FF | 667d |  |
| 130 | 3.10.2 | L1.45.1 - SE Transition Plan | milestone | 0d | 2018-03-01 | 2018-03-01 | 62FF+195d | 667d | 0d |
| 131 | 3.10.3 | Group Transition Commencement Criteria met |  | 97d | 2018-01-18 | 2018-06-01 | 132FF | 601d |  |
| 132 | 3.10.4 | L1.49 - SE Transition commencement | milestone | 0d | 2018-06-01 | 2018-06-01 | 62FF+261d | 601d | 0d |
| 133 | 3.10.5 | Group Transition Completion Report delivered and approved |  | 30d | 2019-06-21 | 2019-08-01 | 135FF | 297d |  |
| 134 | 3.10.6 | L1.61 - SE Transition complete | milestone | 0d | 2019-06-03 | 2019-06-03 | 62FF+522d | 340d |  |
| 135 | 3.11 | **Wales** |  | 367d | 2018-03-07 | 2019-08-01 |  | 297d | 0d |
| 136 | 3.11.1 | Group Transition Plan delivered and approved |  | 40d | 2018-03-07 | 2018-05-01 | 137FF | 624d |  |
| 137 | 3.11.2 | L1.41 - Wales Transition Plan | milestone | 0d | 2018-05-01 | 2018-05-01 | 62FF+238d | 624d | 0d |
| 138 | 3.11.3 | Group Transition Commencement Criteria met |  | 93d | 2018-03-26 | 2018-08-01 | 139FF | 558d |  |
| 139 | 3.11.4 | L1.45 - Wales Transition commencement | milestone | 0d | 2018-08-01 | 2018-08-01 | 62FF+304d | 558d | 0d |
| 140 | 3.11.5 | Group Transition Completion Report delivered and approved |  | 30d | 2019-06-21 | 2019-08-01 | 141FF | 297d |  |
| 141 | 3.11.6 | L1.57.1 - Wales Transition complete | milestone | 0d | 2019-08-01 | 2019-08-01 | 62FF+565d | 297d | 0d |
| 142 | 3.12 | **Scotland** |  | 367d | 2018-03-07 | 2019-08-01 |  | 297d |  |
| 143 | 3.12.1 | Group Transition Plan delivered and approved |  | 40d | 2018-03-07 | 2018-05-01 | 144FF | 624d |  |
| 144 | 3.12.2 | L1.53 - Scotland Transition Plan | milestone | 0d | 2018-05-01 | 2018-05-01 | 62FF+238d | 624d | 0d |
| 145 | 3.12.3 | Group Transition Commencement Criteria met |  | 93d | 2018-03-26 | 2018-08-01 | 146FF | 558d |  |
| 146 | 3.12.4 | L1.57 - Scotland Transition commencement | milestone | 0d | 2018-08-01 | 2018-08-01 | 62FF+304d | 558d | 0d |
| 147 | 3.12.5 | Group Transition Completion Report delivered and approved |  | 30d | 2019-06-21 | 2019-08-01 | 148FF | 297d |  |
| 148 | 3.12.6 | L1.69 - Scotland Transition complete | milestone | 0d | 2019-08-01 | 2019-08-01 | 62FF+565d | 297d | 0d |

| ID | WBS | Task | Type | Duration | Start | Finish | Predecessors | Total slack | Free slack | Constraint |
| --- | --- | --- | --- | --- | --- | --- | --- | --- | --- | --- |
| 149 | 3.13 | **South West** |  | 365d | 2018-07-10 | 2019-12-02 |  | 210d |  |  |
| 150 | 3.13.1 | Group Transition Plan delivered and approved |  | 40d | 2018-07-10 | 2018-09-03 | 151FF | 535d |  |  |
| 151 | 3.13.2 | L1.51 - SW Transition Plan | milestone | 0d | 2018-09-03 | 2018-09-03 | 62FF+327d | 535d | 0d |  |
| 152 | 3.13.3 | Group Transition Commencement Criteria met |  | 91d | 2018-07-30 | 2018-12-03 | 153FF | 470d |  |  |
| 153 | 3.13.4 | L1.55 - SW Transition commencement | milestone | 0d | 2018-12-03 | 2018-12-03 | 62FF+392d | 470d | 0d |  |
| 154 | 3.13.5 | Group Transition Completion Report delivered and approved |  | 30d | 2019-10-22 | 2019-12-02 | 155FF | 210d |  |  |
| 155 | 3.13.6 | L1.67 - SW Transition complete | milestone | 0d | 2019-12-02 | 2019-12-02 | 62FF+652d | 210d | 0d |  |
| 156 | 3.14 | National Transition Completion Report delivered and approved |  | 30d | 2019-10-22 | 2019-12-02 | 157FF | 210d |  |  |
| 157 | 3.15 | L1.69.1 - Transition fully complete | milestone | 0d | 2019-12-02 | 2019-12-02 | 62FS+652d | 210d | 0d |  |
| 158 | 3.16 | **Exit Plan** |  | 70d | 2019-12-31 | 2020-04-06 |  | 120d |  |  |
| 159 | 3.16.1 | Exit Plan delivered and approved |  | 30d | 2019-12-31 | 2020-04-06 | 1FF+1200d | 120d | 0d | start no earlier than 2017-09-25 |
| 160 | 3.16.2 | L1.70 - Exit Plan | milestone | 0d | 2020-04-06 | 2020-04-06 | 159FF | 120d |  |  |
| 161 | 3.17 | **Exit Management** |  | 120d | 2020-04-07 | 2020-09-21 |  | 0d |  |  |
| 162 | 3.17.1 | Expiry of the initial terms |  | 120d | 2020-04-07 | 2020-09-21 | 1FF+1320d | 0d |  |  |
| 163 | 3.17.2 | L1.71 - Exit Management | milestone | 0d | 2020-09-21 | 2020-09-21 | 162FF | 0d |  |  |
